# SOW 3.1 Project Plan v1

How a schedule from MS Project changed from version to version. A marks actual dates.

## Version 1 (saved 2003-02-18, file sow_3.2_project_plan_v8_hUvcQtT.mpp)

| ID | WBS | Task | Duration | Start | Finish | Complete | Total float | Constraint |
| --- | --- | --- | --- | --- | --- | --- | --- | --- |
| 1 | 1 | **NPAC Release 3.2 Implementation** | 284d | 2002-06-01 A | 2003-06-18 | 75% | 0d |  |
| 2 | 1.1 | **Phase 1.0** | 217d | 2002-06-01 A | 2003-03-28 | 93% | 67d |  |
| 3 |  | Effective Start Date | 0d | 2002-06-01 A | 2002-06-01 A | 100% |  | start no earlier than 2001-07-16 |
| 4 |  | Release Package to NAPM LLC | 1d | 2002-06-01 A | 2002-06-03 A | 100% |  | start no earlier than 2001-07-16 |
| 5 |  | SOW Effective Date | 0d | 2002-06-30 A | 2002-06-30 A | 100% |  | start no earlier than 2001-08-24 |
| 6 | 1.1.4 | **Phase 1.1 Develop SOW Project Plan** | 35d | 2002-08-01 A | 2002-09-18 A | 100% |  |  |
| 7 |  | Draft Project Plan delivered to LLC | 1d | 2002-08-01 A | 2002-08-01 A | 100% |  | start no earlier than 2002-08-01 |
| 8 |  | Project Plan - Review | 8d | 2002-08-01 A | 2002-08-12 A | 100% |  | start no earlier than 2002-08-01 |
| 9 |  | Project Plan Final Delivery | 27d | 2002-08-13 A | 2002-09-18 A | 100% |  | finish no earlier than 2002-09-18 |
| 10 | 1.1.5 | **Phase 1.2 Design and Develop Enhancement** | 217d | 2002-06-03 A | 2003-03-28 | 95% | 67d |  |
| 11 | 1.1.5.1 | **GDMO/ASN.1 Spec Completion** | 24d | 2002-07-24 A | 2002-08-26 A | 100% |  |  |
| 12 |  | GDMO/ASN.1 Draft #1 published on web site | 1d | 2002-07-24 A | 2002-07-24 A | 100% |  | start no earlier than 2002-07-24 |
| 13 |  | GDMO/ASN.1 Draft #1 review period by Industry | 4d | 2002-07-25 A | 2002-07-30 A | 100% |  | start no earlier than 2002-07-25 |
| 14 |  | GDMO/ASN.1 Draft #2 published on web site | 1d | 2002-08-22 A | 2002-08-22 A | 100% |  | start no earlier than 2002-08-22 |
| 15 |  | GDMO/ASN.1 Draft #2 review period by Industry | 2d | 2002-08-23 A | 2002-08-26 A | 100% |  | start no earlier than 2002-08-23 |
| 16 |  | GDMO/ASN.1 Final Version distributed | 1d | 2002-08-26 A | 2002-08-26 A | 100% |  | start no earlier than 2002-08-26 |
| 17 | 1.1.5.2 | **FRS Integrated Document Completion** | 40d | 2002-08-09 A | 2002-10-03 A | 100% |  |  |
| 18 |  | FRS Draft #1 Integrated Document distributed to Industry | 1d | 2002-08-09 A | 2002-08-09 A | 100% |  | start no earlier than 2002-08-09 |
| 19 |  | FRS Draft #1 review period by Industry | 5d | 2002-08-12 A | 2002-08-16 A | 100% |  | start no earlier than 2002-08-12 |
| 20 |  | FRS Draft #2 Integrated Document distributed to Industry | 1d | 2002-09-03 A | 2002-09-03 A | 100% |  | start no earlier than 2002-09-03 |
| 21 |  | FRS Draft #2 review period by Industry | 11d | 2002-09-04 A | 2002-09-18 A | 100% |  | start no earlier than 2002-09-04 |
| 22 |  | FRS Proposed Final Integrated Document | 1d | 2002-09-23 A | 2002-09-23 A | 100% |  | start no earlier than 2002-09-23 |
| 23 |  | FRS Final Integrated Document (3.2.0a) | 1d | 2002-10-03 A | 2002-10-03 A | 100% |  | start no earlier than 2002-09-23 |
| 24 | 1.1.5.3 | **IIS Integrated Document Completion** | 33d | 2002-09-06 A | 2002-10-22 A | 100% |  |  |
| 25 |  | IIS Draft #1 Integrated Document distributed to Industry | 1d | 2002-09-06 A | 2002-09-06 A | 100% |  | start no earlier than 2002-09-06 |
| 26 |  | IIS Draft #1 review period by Industry | 8d | 2002-09-09 A | 2002-09-18 A | 100% |  | start no earlier than 2002-09-09 |
| 27 |  | IIS Draft #2 Integrated Document distributed to Industry (3.2.0a) | 1d | 2002-10-03 A | 2002-10-03 A | 100% |  | start no earlier than 2002-10-03 |
| 28 |  | IIS Draft #2 review period by Industry (3.2.0a) | 9d | 2002-10-04 A | 2002-10-16 A | 100% |  | finish no earlier than 2002-10-16 |
| 29 |  | IIS Final Integrated Document (3.2.0a) Review produced no changes. | 1d | 2002-10-22 A | 2002-10-22 A | 100% |  | start no earlier than 2002-10-22 |
| 30 | 1.1.5.4 | **M&P Development Completion** | 26d | 2003-02-21 | 2003-03-28 |  | 67d |  |
| 31 |  | M&Ps Draft #1 distributed to Industry | 1d | 2003-02-21 | 2003-02-21 |  | 90d | start no earlier than 2003-02-21 |
| 32 |  | M&Ps Draft #1 review period by Industry | 5d | 2003-02-24 | 2003-02-28 |  | 85d | start no earlier than 2003-02-24 |
| 33 |  | M&Ps Draft #2 distributed to Industry | 1d | 2003-03-13 | 2003-03-13 |  | 76d | start no earlier than 2003-03-13 |
| 34 |  | M&Ps Draft #2 review period by Industry | 5d | 2003-03-14 | 2003-03-20 |  | 71d | start no earlier than 2003-03-14 |
| 35 |  | FINAL Publishing of M&Ps (SLR 26) | 1d | 2003-03-28 | 2003-03-28 |  | 65d | start no earlier than 2003-03-28 |
| 36 |  | Delta Change Order document completed | 19d | 2002-09-09 A | 2002-10-03 A | 100% |  | start no earlier than 2002-09-09 |
| 37 |  | Release 3.2 Development Completed | 162d | 2002-06-03 A | 2003-01-10 A | 100% |  | finish no earlier than 2003-01-10 |
| 38 | 1.1.6 | **Phase 1.3 IT&S Testing of the Enhancement** | 121d | 2002-09-16 A | 2003-03-03 | 89% | 86d |  |
| 39 |  | Develop Test Cases | 65d | 2002-09-16 A | 2002-12-13 A | 100% |  | start no earlier than 2002-09-16 |
| 40 |  | Execute Internal testing | 35d | 2003-01-13 A | 2003-02-28 | 70% | 87d | start no earlier than 2003-01-13 |
| 41 |  | NeuStar Software Certification and install on Test bed | 1d | 2003-03-03 | 2003-03-03 |  | 68d | start no earlier than 2003-03-03 |
| 42 |  | Notification of requirements to pass edits to 191, 291, and 319 | 1d | 2003-01-13 A | 2003-01-13 A | 100% |  | finish no earlier than 2003-01-13 |
| 43 | 1.1.7 | **Phase 1.4 Interoperability Testing** | 164d | 2002-07-15 A | 2003-02-27 | 93% | 88d |  |
| 44 | 1.1.7.1 | **Interoperability and Test Cases Completion** | 80d | 2002-08-08 A | 2002-11-27 A | 100% |  |  |
| 45 |  | ITP Test Case List Draft #1 distributed to Industry | 1d | 2002-08-08 A | 2002-08-08 A | 100% |  | start no earlier than 2002-08-08 |
| 46 |  | ITP Test Case List Draft #1 review period by Industry | 21d | 2002-08-09 A | 2002-09-06 A | 100% |  | start no earlier than 2002-08-09 |
| 47 |  | ITP Test Case List Draft #2 distributed to Industry | 1d | 2002-09-19 A | 2002-09-19 A | 100% |  | start no earlier than 2002-09-19 |
| 48 |  | ITP Test Case List Draft #2 review period by Industry | 10d | 2002-09-20 A | 2002-10-03 A | 100% |  | start no earlier than 2002-09-20 |
| 49 |  | ITP Test Cases - Draft #1 - distributed to Industry | 1d | 2002-10-16 A | 2002-10-16 A | 100% |  | start no earlier than 2002-10-16 |
| 50 |  | ITP Test Cases - Draft #1 - review period by Industry | 11d | 2002-10-17 A | 2002-10-31 A | 100% |  | start no earlier than 2002-10-17 |
| 51 |  | ITP Test Cases - Draft #2 - distributed to Industry | 1d | 2002-11-12 A | 2002-11-12 A | 100% |  | start no earlier than 2002-11-12 |
| 52 |  | ITP Test Cases - Draft #2 review period by Industry | 9d | 2002-11-13 A | 2002-11-25 A | 100% |  | start no earlier than 2002-11-13 |
| 53 |  | FINAL Publishing of ITP Test Case | 1d | 2002-11-27 A | 2002-11-27 A | 100% |  | start no earlier than 2002-11-27 |
| 54 | 1.1.7.2 | **ITP Simulator Upgrade** | 160d | 2002-07-15 A | 2003-02-21 | 91% | 92d |  |
| 55 |  | Analyze and Design changes to GDMO and ASN.1 | 25d | 2002-07-15 A | 2002-08-16 A | 100% |  | finish no earlier than 2002-08-16 |
| 56 |  | Coding of changes | 22d | 2002-08-16 A | 2002-09-16 A | 100% |  | start no earlier than 2002-08-16 |
| 57 |  | Testing Modified ITP | 20d | 2002-09-16 A | 2002-10-11 A | 100% |  | finish no earlier than 2002-10-11 |
| 58 |  | Training to NeuStar | 1d | 2002-11-01 A | 2002-11-01 A | 100% |  | start no earlier than 2002-11-01 |
| 59 |  | Interoperability Test Execution with Vendors | 60d | 2002-12-02 A | 2003-02-21 | 80% | 92d | finish no earlier than 2003-02-21 |
| 60 | 1.1.7.3 | **ITP Testing Communication Plan** | 61d | 2002-12-05 A | 2003-02-27 | 85% | 88d |  |
| 61 |  | Weekly SP/Vendor ITP Conference call | 1d | 2002-12-05 A | 2002-12-05 A | 100% |  | start no earlier than 2002-12-05 |
| 62 |  | Weekly SP/Vendor ITP Conference Call | 1d | 2002-12-12 A | 2002-12-12 A | 100% |  | start no earlier than 2002-12-12 |
| 63 |  | Weekly SP/Vendor ITP Conference call | 1d | 2002-12-19 A | 2002-12-19 A | 100% |  | start no earlier than 2002-12-19 |
| 64 |  | Weekly SP/Vendor ITP Conference call | 1d | 2002-12-26 A | 2002-12-26 A | 100% |  | start no earlier than 2002-12-26 |
| 65 |  | Weekly SP/Vendor ITP Conference call | 1d | 2003-01-02 A | 2003-01-02 A | 100% |  | start no earlier than 2003-01-02 |
| 66 |  | Weekly SP/Vendor ITP Conference call | 1d | 2003-01-09 A | 2003-01-09 A | 100% |  | start no earlier than 2003-01-09 |
| 67 |  | Weekly SP/Vendor ITP Conference Call | 1d | 2003-01-16 A | 2003-01-16 A | 100% |  | start no earlier than 2003-01-16 |
| 68 |  | Weekly SP/Vendor ITP Conference Call | 1d | 2003-01-30 A | 2003-01-30 A | 100% |  |  |
| 69 |  | Weekly SP/Vendor ITP Conference Call | 1d | 2003-01-30 A | 2003-01-30 A | 100% |  | start no earlier than 2003-01-30 |
| 70 |  | Weekly SP/Vendor ITP Conference Call | 1d | 2003-02-06 A | 2003-02-06 A | 100% |  | start no earlier than 2003-02-06 |

| ID | WBS | Task | Duration | Start | Finish | Predecessors | Complete | Total float | Constraint |
| --- | --- | --- | --- | --- | --- | --- | --- | --- | --- |
| 71 |  | Weekly SP/Vendor ITP Conference Call | 1d | 2003-02-13 A | 2003-02-13 A |  | 100% |  | start no earlier than 2003-02-13 |
| 72 |  | Weekly SP/Vendor ITP Conference Call | 1d | 2003-02-20 | 2003-02-20 |  |  | 93d | start no earlier than 2003-02-20 |
| 73 |  | Weekly SP/Vendor ITP Conference Call | 1d | 2003-02-27 | 2003-02-27 |  |  | 88d | start no earlier than 2003-02-27 |
| 74 | 1.2 | **Phase 2.0 Turn Up Testing Of Enhancement** | 206d | 2002-08-09 A | 2003-05-16 |  | 38% | 27d |  |
| 75 | 1.2.1 | **Phase 2.1 Turn Up Test Plan and Test Case Completion** | 147d | 2002-08-09 A | 2003-03-03 |  | 85% | 86d |  |
| 76 |  | Turn Up Test Case List Draft #1 distributed to Industry | 1d | 2002-08-09 A | 2002-08-09 A |  | 100% |  | start no earlier than 2002-08-09 |
| 77 |  | Turn Up Test Case List review period by Industry | 27d | 2002-08-13 A | 2002-09-18 A |  | 100% |  | start no earlier than 2002-08-13 |
| 78 |  | Turn Up Test Case List Draft #2 distributed to Industry | 1d | 2002-10-08 A | 2002-10-08 A |  | 100% |  | start no earlier than 2002-10-08 |
| 79 |  | Turn Up Test Case List Draft #2 review period by Industry | 10d | 2002-10-09 A | 2002-10-22 A |  | 100% |  | start no earlier than 2002-10-09 |
| 80 |  | Turn Up Test Cases - Draft #1 distributed to Industry | 1d | 2002-11-22 A | 2002-11-22 A |  | 100% |  | start no earlier than 2002-11-22 |
| 81 |  | Turn Up Test Cases - Draft #1 review period by Industry | 16d | 2002-11-25 A | 2002-12-16 A |  | 100% |  | finish no earlier than 2002-12-16 |
| 82 |  | Turn UP Test Cases - Review Conf call | 2d | 2002-12-17 A | 2002-12-18 A |  | 100% |  | start no earlier than 2002-12-17 |
| 83 |  | Turn Up Test Cases - Draft #2 distributed to Industry | 1d | 2003-01-17 A | 2003-01-17 A |  | 100% |  | start no earlier than 2003-01-17 |
| 84 |  | Turn Up Test Cases - Draft #2 review period by Industry | 15d | 2003-01-20 A | 2003-02-07 A |  | 100% |  | start no earlier than 2003-01-20 |
| 85 |  | FINAL Publishing of Turn Up Test Plan for R3.2 | 1d | 2003-02-14 | 2003-02-14 |  |  | 97d | start no earlier than 2003-02-14 |
| 86 |  | SP Certification & Regression Test Plan with mods for R3.2, distributed to Industry | 1d | 2003-02-18 | 2003-02-18 |  |  | 95d | finish no earlier than 2003-02-18 |
| 87 |  | SP Certification & Regression Test Plan with mods for R3.2, review period by Industry | 10d | 2003-02-18 | 2003-03-03 |  |  | 86d | finish no earlier than 2003-03-03 |
| 88 |  | FINAL Publishing of Turn Up Test Plan, REGRESSION PORTION | 1d | 2003-03-03 | 2003-03-03 |  |  | 86d | finish no earlier than 2003-03-03 |
| 89 | 1.2.2 | **Phase 2.2 Turn Up Test Execution** | 69d | 2003-02-18 | 2003-05-16 |  |  | 27d |  |
| 90 |  | Sample BDD and SMURF files distributed for NANC 169, 354, and 323 | 1d | 2003-02-18 | 2003-02-18 |  |  | 95d | start no earlier than 2003-02-18 |
| 91 | 1.2.2.2 | **Turn Up Testing Communication Plan** | 57d | 2003-03-05 | 2003-05-15 |  |  | 28d |  |
| 92 |  | Daily TUT Status reports | 40d | 2003-03-05 | 2003-04-25 |  |  | 45d | finish no earlier than 2003-04-25 |
| 93 |  | Weekly SP TUT Conference call | 1d | 2003-03-06 | 2003-03-06 |  |  | 83d | start no earlier than 2003-03-06 |
| 94 |  | Weekly SP TUT Conference call | 1d | 2003-03-13 | 2003-03-13 |  |  | 78d | start no earlier than 2003-03-13 |
| 95 |  | Weekly SP TUT Conference call | 1d | 2003-03-20 | 2003-03-20 |  |  | 73d | start no earlier than 2003-03-20 |
| 96 |  | Weekly SP TUT Conference call | 1d | 2003-03-27 | 2003-03-27 |  |  | 68d | start no earlier than 2003-03-27 |
| 97 |  | Weekly SP TUT Conference call | 1d | 2003-04-03 | 2003-04-03 |  |  | 62d | start no earlier than 2003-04-03 |
| 98 |  | Weekly SP TUT Conference call | 1d | 2003-04-10 | 2003-04-10 |  |  | 57d | start no earlier than 2003-04-10 |
| 99 |  | Weekly SP TUT Conference call | 1d | 2003-04-17 | 2003-04-17 |  |  | 51d | start no earlier than 2003-04-17 |
| 100 |  | Weekly SP TUT Conference call | 1d | 2003-04-24 | 2003-04-24 |  |  | 46d | start no earlier than 2003-04-24 |
| 101 |  | Weekly SP TUT Conference call | 1d | 2003-05-01 | 2003-05-01 |  |  | 39d | start no earlier than 2003-05-01 |
| 102 |  | Weekly SP TUT Conference call | 1d | 2003-05-08 | 2003-05-08 |  |  | 34d | start no earlier than 2003-05-08 |
| 103 |  | Weekly SP TUT Conference call | 1d | 2003-05-15 | 2003-05-15 |  |  | 28d | start no earlier than 2003-05-15 |
| 104 | 1.2.2.3 | **SP Release 3.2 Testing** | 60d | 2003-03-03 | 2003-05-16 |  |  | 27d |  |
| 105 |  | SP Individual Testing Session | 42d | 2003-03-03 | 2003-04-25 |  |  | 31d | start no earlier than 2003-03-03 |
| 106 |  | SP Group and Performance Testing | 14d | 2003-04-28 | 2003-05-14 | 105 |  | 29d | finish no earlier than 2003-05-14 |
| 107 |  | SP Failover Testing | 2d | 2003-05-15 | 2003-05-16 |  |  | 27d | start no earlier than 2003-05-15 |
| 108 | 1.3 | **Phase 3.0 Roll Out of Enhancement** | 128d | 2003-01-03 A | 2003-06-18 |  | 2% | 0d |  |
| 109 |  | EMW (Enhanced Maintenance Window) Blanket Request Completion | 1d | 2003-01-03 A | 2003-01-03 |  | 70% | 127d | start no earlier than 2003-01-03 |
| 110 |  | Notification of delivery to Industry (SLR 24) | 1d | 2003-03-07 | 2003-03-07 |  |  | 82d | start no earlier than 2003-03-07 |
| 111 |  | LLC/PEs Identify sequence of region installation | 1d | 2003-03-21 | 2003-03-21 |  |  | 72d | start no earlier than 2003-03-21 |
| 112 | 1.3.4 | **Region 1 Install 3.2 Release** | 36d | 2003-04-18 | 2003-05-30 |  |  | 15d |  |
| 113 |  | Provide 30 day notification | 1d | 2003-04-18 | 2003-04-18 |  |  | 50d | start no earlier than 2003-04-18 |
| 114 |  | Send out SP Profile Questionaire | 1d | 2003-04-28 | 2003-04-28 |  |  | 42d | start no earlier than 2003-04-28 |
| 115 |  | Preliminary Go/No Go Decision | 1d | 2003-05-02 | 2003-05-02 |  |  | 38d | start no earlier than 2003-05-02 |
| 116 |  | SPs profile information due to NeuStar | 1d | 2003-05-05 | 2003-05-05 |  |  | 37d | start no earlier than 2003-05-05 |
| 117 |  | NPAC Taken down for H/w S/w install | 1d | 2003-05-18 | 2003-05-18 |  |  | 26d | start no earlier than 2003-05-18 |
| 118 |  | Region 1 Final Go-NoGo decision | 0d | 2003-05-18 | 2003-05-18 |  |  | 27d | start no earlier than 2003-05-18 |
| 119 |  | Install Rel 3.2 Production Software | 1d | 2003-05-18 | 2003-05-18 |  |  | 26d | start no earlier than 2003-05-18 |
| 120 |  | Region 1 General Availability | 0d | 2003-05-19 | 2003-05-19 |  |  | 26d | start no earlier than 2003-05-19 |
| 121 |  | Region 1 Contigency Plan conference call | 0d | 2003-05-19 | 2003-05-19 |  |  | 26d | start no earlier than 2003-05-19 |
| 122 |  | Region 1 Soak Period | 11d | 2003-05-19 | 2003-05-30 |  |  | 15d | start no earlier than 2003-05-19 |
| 124 | 1.3.5 | **Regions 2,3 and 4 Install 3.2 Release** | 35d | 2003-05-02 | 2003-06-13 |  |  | 4d |  |
| 125 |  | Provide 30 day notification | 1d | 2003-05-02 | 2003-05-02 |  |  | 38d | start no earlier than 2003-05-02 |
| 126 |  | Send out SP Profile Questionaire | 1d | 2003-05-12 | 2003-05-12 |  |  | 31d | start no earlier than 2003-05-12 |
| 127 |  | Preliminary Go/No Go decision | 1d | 2003-05-16 | 2003-05-16 |  |  | 27d | start no earlier than 2003-05-16 |
| 128 |  | SPs profile information due to NeuStar | 1d | 2003-05-19 | 2003-05-19 |  |  | 25d | start no earlier than 2003-05-19 |
| 129 |  | NPAC Taken down for H/w S/w install | 1d | 2003-06-01 | 2003-06-01 |  |  | 14d | start no earlier than 2003-06-01 |
| 130 |  | Regions 2,3 and 4 Final Go-NoGo decision | 0d | 2003-06-01 | 2003-06-01 |  |  | 15d | start no earlier than 2003-06-01 |
| 131 |  | Install Rel 3.2 Production Software | 0d | 2003-06-01 | 2003-06-01 |  |  | 15d | start no earlier than 2003-06-01 |
| 132 |  | Regions 2,3 and 4 General Availability | 0d | 2003-06-02 | 2003-06-02 |  |  | 14d | start no earlier than 2003-06-02 |
| 133 |  | Regions 2,3 and 4 Contigency Plan conference call | 0d | 2003-06-02 | 2003-06-02 |  |  | 14d | start no earlier than 2003-06-02 |
| 134 |  | Regions 2,3 and 4 Soak Period | 10d | 2003-06-02 | 2003-06-13 |  |  | 4d | start no earlier than 2003-06-02 |
| 136 | 1.3.6 | **Regions 5,6 and 7 Install 3.2 Release** | 26d | 2003-05-16 | 2003-06-16 |  |  | 2d |  |
| 137 |  | Provide 30 day notification | 1d | 2003-05-16 | 2003-05-16 |  |  | 27d | start no earlier than 2003-05-16 |
| 138 |  | Send out SP Profile Questionaire | 1d | 2003-05-26 | 2003-05-26 |  |  | 19d | start no earlier than 2003-05-26 |
| 139 |  | Preliminary Go/No Go decision | 1d | 2003-05-30 | 2003-05-30 |  |  | 15d | start no earlier than 2003-05-30 |
| 140 |  | SPs profile information due to NeuStar | 1d | 2003-06-02 | 2003-06-02 |  |  | 13d | start no earlier than 2003-06-02 |
| 141 |  | NPAC Taken down for H/w S/w install | 1d | 2003-06-15 | 2003-06-15 |  |  | 3d | start no earlier than 2003-06-15 |
| 142 |  | Regions 5,6 and 7 Final Go-NoGo decision | 0d | 2003-06-15 | 2003-06-15 |  |  | 4d | start no earlier than 2003-06-15 |

| ID | WBS | Task | Duration | Start | Finish | Total float | Constraint |
| --- | --- | --- | --- | --- | --- | --- | --- |
| 143 |  | Install Rel 3.2 Production Software | 1d | 2003-06-15 | 2003-06-15 | 3d | start no earlier than 2003-06-15 |
| 144 |  | Regions 5,6 and 7 General Availability | 0d | 2003-06-16 | 2003-06-16 | 3d | start no earlier than 2003-06-16 |
| 145 |  | Regions 5,6 and 7 Contigency Plan conference call | 1d | 2003-06-16 | 2003-06-16 | 2d | start no earlier than 2003-06-16 |
| 147 |  | Send Notice to clean up DPC and LRN data in existing SVs | 1d | 2003-06-18 | 2003-06-18 | 0d | start no earlier than 2003-06-18 |
| 149 | 1.4 | **SOW Close out** | 0d | 2003-06-16 | 2003-06-16 | 3d |  |
| 150 |  | Issue letter to PEs Results of Installation | 0d | 2003-06-16 | 2003-06-16 | 3d | start no earlier than 2003-06-16 |
| 151 |  | Post Mortem Conference Call | 0d | 2003-06-16 | 2003-06-16 | 3d | start no earlier than 2003-06-16 |

## Version 2 (saved 2003-03-11, file sow_3.2_project_plan_v_9_74NfXWy.mpp)

Last finish stays 2003-06-18. Complete tasks 59 → 75.

Changed:

| ID | Task | Start | Finish | Complete | Total float | Other |
| --- | --- | --- | --- | --- | --- | --- |
| 1 | **NPAC Release 3.2 Implementation** |  |  | 75% → 82% |  |  |
| 2 | **Phase 1.0** |  |  | 93% → 99% | 67d → 65d |  |
| 10 | **Phase 1.2 Design and Develop Enhancement** |  |  | 95% → 97% | 67d → 65d |  |
| 30 | **M&P Development Completion** | 2003-02-21 A |  | 0% → 46% | 67d → 65d |  |
| 31 | M&Ps Draft #1 distributed to Industry | 2003-02-21 A | 2003-02-21 A | 0% → 100% | 90d → none |  |
| 32 | M&Ps Draft #1 review period by Industry | 2003-02-24 A | 2003-02-28 A | 0% → 100% | 85d → none |  |
| 38 | **Phase 1.3 IT&S Testing of the Enhancement** |  | 2003-03-03 A | 89% → 100% | 86d → none |  |
| 40 | Execute Internal testing |  | 2003-02-28 A | 70% → 100% | 87d → none |  |
| 41 | NeuStar Software Certification and install on Test bed | 2003-03-03 A | 2003-03-03 A | 0% → 100% | 68d → none |  |
| 43 | **Phase 1.4 Interoperability Testing** |  | 2003-02-27 A | 93% → 100% | 88d → none |  |
| 54 | **ITP Simulator Upgrade** |  | 2003-02-21 A | 91% → 100% | 92d → none |  |
| 59 | Interoperability Test Execution with Vendors |  | 2003-02-21 A | 80% → 100% | 92d → none |  |
| 60 | **ITP Testing Communication Plan** |  | 2003-02-27 A | 85% → 100% | 88d → none |  |
| 72 | Weekly SP/Vendor ITP Conference Call | 2003-02-20 A | 2003-02-20 A | 0% → 100% | 93d → none |  |
| 73 | Weekly SP/Vendor ITP Conference Call | 2003-02-27 A | 2003-02-27 A | 0% → 100% | 88d → none |  |
| 74 | **Phase 2.0 Turn Up Testing Of Enhancement** |  |  | 38% → 49% |  |  |
| 75 | **Phase 2.1 Turn Up Test Plan and Test Case Completion** |  | 2003-03-03 A | 85% → 100% | 86d → none |  |
| 85 | FINAL Publishing of Turn Up Test Plan for R3.2 | 2003-02-14 A | 2003-02-14 A | 0% → 100% | 97d → none |  |
| 86 | SP Certification & Regression Test Plan with mods for R3.2, distributed to Industry | 2003-02-18 A | 2003-02-18 A | 0% → 100% | 95d → none |  |
| 87 | SP Certification & Regression Test Plan with mods for R3.2, review period by Industry | 2003-02-18 A | 2003-03-03 A | 0% → 100% | 86d → none |  |
| 88 | FINAL Publishing of Turn Up Test Plan (3.2.0a). Review produced no changes. | 2003-03-03 A | 2003-03-03 A | 0% → 100% | 86d → none | was named FINAL Publishing of Turn Up Test Plan, REGRESSION PORTION |
| 89 | **Phase 2.2 Turn Up Test Execution** | 2003-02-18 A |  | 0% → 8% |  |  |
| 90 | Sample BDD and SMURF files distributed for NANC 169, 354, and 323 | 2003-02-18 A | 2003-02-18 A | 0% → 100% | 95d → none |  |
| 91 | **Turn Up Testing Communication Plan** | 2003-03-05 A |  | 0% → 16% |  |  |
| 92 | Daily TUT Status reports | 2003-03-05 A |  | 0% → 15% |  |  |
| 93 | Weekly SP TUT Conference call | 2003-03-06 A | 2003-03-06 A | 0% → 100% | 83d → none |  |
| 94 | Weekly SP TUT Conference call | 2003-03-13 A | 2003-03-13 A | 0% → 100% | 78d → none |  |
| 108 | **Phase 3.0 Roll Out of Enhancement** |  |  | 2% → 6% |  |  |
| 110 | Notification of completion of IT&S Acceptance | 2003-03-07 → 2003-03-06 A (-1d) | 2003-03-07 → 2003-03-06 A (-1d) | 0% → 100% | 82d → none | was named Notification of delivery to Industry (SLR 24); constraint start no earlier than 2003-03-07 → start no earlier than 2003-03-06 |
| 111 | LLC/PEs Identify sequence of region installation | 2003-03-21 → 2003-01-31 A (-49d) | 2003-03-21 → 2003-01-31 A (-49d) | 0% → 100% | 72d → none | constraint start no earlier than 2003-03-21 → start no earlier than 2003-01-31 |
| 112 | **Region 1 (Mid West) Install 3.2 Release** |  |  |  |  | was named Region 1 Install 3.2 Release |
| 113 | Provide 30 day notification (SLR 24) |  |  |  |  | was named Provide 30 day notification |
| 124 | **Regions 2,3 and 4 (MAtlantic, S East and S West) Install 3.2 Release** |  |  |  |  | was named Regions 2,3 and 4 Install 3.2 Release |
| 136 | **Regions 5,6 and 7 (N East, W Coast and Western) Install 3.2 Release** |  |  |  |  | was named Regions 5,6 and 7 Install 3.2 Release |
